# SUBPROYECTO A4 - PAMPA DEL TORO

Schedule from Primavera P6, 2022-11-01 to 2022-12-30, data date 2022-11-01.

## Calendars

- OHLA: Mon-Sun 07:00-12:00, 13:00-18:00.

## Resources

| Resource | Group | Notes |
| --- | --- | --- |
| HH MAHRTUNEL | labor | ? |
| ROCA | material |  |

## Schedule

| ID | WBS | Activity | Type | Duration | Start | Finish | Predecessors | Total float | Free float |
| --- | --- | --- | --- | --- | --- | --- | --- | --- | --- |
|  | 1 | **HITOS DEL PROYECTO** |  |  | 2022-11-01 | 2022-12-30 |  |  |  |
| HP.010 |  | INICIO DE DE OBRA - ACCESO AL SITIO (Después de la firma del Acta de Entrega de Terreno) | milestone | 0d | 2022-11-01 | 2022-11-01 |  | 0d |  |
| HP.020 |  | INICIO DE EXCAVACIÓN | milestone | 0d | 2022-12-01 | 2022-12-01 | D.03.010 SS | 30d |  |
| HP.030 |  | INICIO DE RELLENO DE DIQUE | milestone | 0d | 2022-12-05 | 2022-12-05 | D.04.030 SS | 26d |  |
| HP.040 |  | CULMINACIÓN DE OBRAS | milestone | 0d | 2022-12-30 | 2022-12-30 | PCO.010, D.05.110, PCO.040, TP.050, OP.030 | 0d |  |
|  | 2 | **TRABAJOS PRELIMINARES** |  |  | 2022-11-01 | 2022-12-30 |  |  |  |
| TP.010 |  | MOVILIZACIÓN DE RECURSOS (PERSONAL, EQUIPOS, MATERIALES) |  | 15d | 2022-11-01 | 2022-11-15 | HP.010 | 0d |  |
| TP.020 |  | ELABORACIÓN DE DOCUMENTOS ENTRE SUBCONTRATISTA Y OHLA |  | 10d | 2022-11-01 | 2022-11-10 | HP.010 | 0d |  |
| TP.030 |  | APROBACIÓN DE DOCUMENTOS ENTRE SUBCONTRATISTA Y OHLA |  | 5d | 2022-11-11 | 2022-11-15 | TP.020 | 0d |  |
| TP.050 |  | TOPOGRAFIA Y GEOREFRENCIACIÓN DE OBRA |  | 45d | 2022-11-16 | 2022-12-30 | TP.010 | 0d |  |
|  | 3 | **OBRAS PRELIMINARES** |  |  | 2022-11-21 | 2022-12-25 |  |  |  |
| OP.030 |  | MANTENIMIENTO DE TRANSITO Y SEGURIDAD VIAL |  | 35d | 2022-11-21 | 2022-12-25 | MV.020 | 5d |  |
| OP.010 |  | INSTALACIONES PROVISIONALES PARA LA OBRA |  | 5d | 2022-11-29 | 2022-12-03 | MV.040 SS+5d | 27d | 0d |
| OP.020 |  | CARTEL DE IDENTIFICACIÓN DE OBRA 4.8 m x 3.60 m |  | 1d | 2022-12-01 | 2022-12-01 | OP.010 SS+2d | 29d |  |
|  | C | **CONSTRUCCIÓN** |  |  | 2022-11-16 | 2022-12-30 |  |  |  |
|  | 70 | **OBRAS EXTERIORES** |  |  | 2022-11-16 | 2022-12-30 |  |  |  |
|  | 02 | **CARRETERAS, CAMINOS, PAVIMENTOS** |  |  | 2022-11-16 | 2022-12-06 |  |  |  |
|  | 01 | **MEJORAMIENTO DE VIAS EXISTENTES** |  |  | 2022-11-16 | 2022-12-06 |  |  |  |
|  | 01 | **MOVIMIENTO DE TIERRAS** |  |  | 2022-11-16 | 2022-11-26 |  |  |  |
| MV.010 |  | ROCE Y LIMPIEZA DE MALEZA |  | 5d | 2022-11-16 | 2022-11-20 | TP.010, TP.030 | 0d |  |
| MV.020 |  | MEJORAMIENTO DE VIAS EXISTENTES - VIA DE ACCESO A DME 13 |  | 3d | 2022-11-18 | 2022-11-20 | MV.010 SS+2d | 0d |  |
| MV.030 |  | MEJORAMIENTO DE VIAS EXISTENTES - VIA DE ACCESO A DIQUE MI |  | 3d | 2022-11-21 | 2022-11-23 | MV.020 | 0d |  |
| MV.040 |  | MEJORAMIENTO DE VIAS EXISTENTES - VIA DE ACCESO A DIQUE MD |  | 3d | 2022-11-24 | 2022-11-26 | MV.030 | 0d |  |
|  | 02 | **REPOSICIÓN DE ESTRUCTURAS** |  |  | 2022-11-21 | 2022-12-06 |  |  |  |
| RE.010 |  | DEMOLICIÓN DE ESTRUCTURAS EXISTENTES |  | 4d | 2022-11-21 | 2022-11-24 | MV.020 | 24d | 0d |
| RE.060 |  | MONTAJE DE LOSA CONCRETO 1.6mx1.0mx0.20m EN PASE DE AGUA |  | 2d | 2022-11-24 | 2022-11-25 | MV.030 | 2d | 1d |
| RE.020 |  | REPOSICIÓN DE PASE DE AGUA TUBERÍA HDPE CORRUGADA Ø=24" |  | 4d | 2022-11-25 | 2022-11-28 | RE.010 | 24d | 0d |
| RE.040 |  | REPOSICIÓN DE PASE DE AGUA TUBERÍA HDPE CORRUGADA Ø=36" |  | 4d | 2022-11-25 | 2022-11-28 | RE.020 SS | 24d | 0d |
| RE.030 |  | ESTRUCTURA DE CONCRETO 175 Kg/cm2 DE CABEZAL ENTRADA Y SALIDA DE TUB. HDPE CORRUGADA Ø=24" |  | 8d | 2022-11-29 | 2022-12-06 | RE.020 | 24d | 0d |
| RE.050 |  | ESTRUCTURA DE CONCRETO 175 Kg/cm2 DE CABEZAL ENTRADA Y SALIDA DE TUB. HDPE CORRUGADA Ø=36" |  | 8d | 2022-11-29 | 2022-12-06 | RE.040, RE.030 SS | 24d |  |

| ID | WBS | Activity | Duration | Start | Finish | Predecessors | Total float | Free float | Resources |
| --- | --- | --- | --- | --- | --- | --- | --- | --- | --- |
|  | 00 | **GENERAL** |  | 2022-11-21 | 2022-12-30 |  |  |  |  |
|  | 03 | **PROGRAMA DE CIERRE DE OBRA** |  | 2022-11-21 | 2022-12-30 |  |  |  |  |
| PCO.010 |  | RESTAURACIÓN DE ÁREAS DE INSTALACIONES PROVISIONALES | 3d | 2022-12-28 | 2022-12-30 | RC.040, D.05.110, PLR-01-050, I-03.090 | 0d |  |  |
|  | 2 | **ACONDICIONAMIENTO DE DEPÓSITOS DE MATERIALES EXCEDENTES** |  | 2022-11-21 | 2022-12-24 |  |  |  |  |
| PCO.020 |  | RETIRO Y ALMACENAMIENTO DE TOPSOIL DEL DME | 4d | 2022-11-21 | 2022-11-24 | MV.020 | 20d | 6d |  |
| PCO.030 |  | ACONDICIONAMIENTO DE MATERIAL EN BOTADERO | 16d | 2022-12-01 | 2022-12-16 | D.03.010 SS, PCO.020 | 14d |  |  |
| PCO.040 |  | COLOCACIÓN DE CAPA SUPERFICIAL DEL DME | 4d | 2022-12-21 | 2022-12-24 | D.03.015, D.05.020, D.05.040, RC.020 | 6d |  |  |
|  | 14 | **REFUERZO DE RIBERA DEL RIO** |  | 2022-11-27 | 2022-12-27 |  |  |  |  |
|  | 5 | **PROTECCIÓN DEL CAUCE CON ENROCADO (A4-PT-PLR-01)-AGUAS ABAJO** |  | 2022-11-27 | 2022-12-04 |  |  |  |  |
| PLR-01-010 |  | DESBROCE Y LIMPIEZA EN ZONA NO BOSCOSA | 1d | 2022-11-27 | 2022-11-27 | MV.040, RE.060 | 1d | 0d |  |
| PLR-01-020 |  | EXCAVACIÓN EN MATERIAL SUELTO CON EQUIPO | 2d | 2022-11-28 | 2022-11-29 | PLR-01-010 | 1d | 0d |  |
| PLR-01-030 |  | PERFILADO Y COMPACTACIÓN CON EQUIPO DE FONDO DE EXCAVACIÓN | 2d | 2022-11-29 | 2022-11-30 | PLR-01-020 FF+1d | 1d | 0d |  |
| PLR-01-040 |  | TRANSPORTE DE ROCA | 5d | 2022-11-29 | 2022-12-03 | PLR-01-030 SS | 3d | 0d | ROCA [541] |
| PLR-01-050 |  | COLOCACIÓN DE ROCA EN CAUCE | 5d | 2022-11-30 | 2022-12-04 | PLR-01-040 SS+1d | 3d | 2d |  |
|  | 10 | **PROTECCION DE TALUDES (A4-PT-D-03)** |  | 2022-12-01 | 2022-12-12 |  |  |  |  |
| D.03.010 |  | DESBROCE Y LIMPIEZA EN ZONA NO BOSCOSA | 1d | 2022-12-01 | 2022-12-01 | PLR-01-030 | 1d | 0d |  |
| D.03.015 |  | TRANSPORTE DE MATERIAL EXCEDENTE | 1d | 2022-12-01 | 2022-12-01 | D.03.010 SS | 25d | 19d |  |
| D.03.020 |  | RELLENO ESTRUCTURAL CON MATERIAL PROPIO EN TALUD EXISTENTE | 2d | 2022-12-02 | 2022-12-03 | D.03.010 | 1d | 0d |  |
| D.03.030 |  | EXCAVACIÓN EN TERRENO NATURAL CON EQUIPO | 1d | 2022-12-04 | 2022-12-04 | D.03.020 | 1d | 0d |  |
| D.03.040 |  | PERFILADO Y COMPACTACIÓN EN ZONA DE CORTE | 1d | 2022-12-05 | 2022-12-05 | D.03.030 | 1d | 0d |  |
| D.03.060 |  | COLOCACIÓN DE GEOTEXTIL NO TEJIDO 400 gr/m2 | 1d | 2022-12-06 | 2022-12-06 | D.03.040 | 1d | 0d |  |
| D.03.070 |  | TRANSPORTE DE ROCA | 6d | 2022-12-06 | 2022-12-11 | D.03.060 SS | 1d | 0d | ROCA [108] |
| D.03.080 |  | COLOCACIÓN Y ACOMODO DE ROCA EN UÑA DEL DIQUE | 2d | 2022-12-07 | 2022-12-08 | D.03.070 SS+1d, PLR-01-050 | 1d | 0d |  |
| D.03.090 |  | COLOCACIÓN Y ACOMODO DE ROCA EN TALUD DEL DIQUE | 4d | 2022-12-09 | 2022-12-12 | D.03.080 | 1d | 0d |  |

| ID | WBS | Activity | Duration | Start | Finish | Predecessors | Total float | Free float | Resources |
| --- | --- | --- | --- | --- | --- | --- | --- | --- | --- |
|  | 1 | **PROTECCION DE TALUDES (A4-PT-I-02)** |  | 2022-12-06 | 2022-12-18 |  |  |  |  |
| I-02.010 |  | DESBROCE Y LIMPIEZA EN ZONA NO BOSCOSA | 1d | 2022-12-06 | 2022-12-06 | D.03.040 | 1d | 0d | HH MAHRTUNEL [23 h] |
| I-02.020 |  | TRANSPORTE DE MATERIAL EXCEDENTE | 1d | 2022-12-06 | 2022-12-06 | I-02.010 SS | 24d |  | HH MAHRTUNEL [227.1 h] |
| I-02.030 |  | RELLENO ESTRUCTURAL CON MATERIAL PROPIO EN TALUD EXISTENTE | 2d | 2022-12-07 | 2022-12-08 | I-02.010 | 1d | 0d |  |
| I-02.040 |  | EXCAVACIÓN EN TERRENO NATURAL CON EQUIPO | 2d | 2022-12-09 | 2022-12-10 | I-02.030 | 1d | 0d | HH MAHRTUNEL [56 h] |
| I-02.050 |  | PERFILADO Y COMPACTACIÓN EN ZONA DE CORTE | 2d | 2022-12-10 | 2022-12-11 | I-02.040 FF+1d | 1d | 0d | HH MAHRTUNEL [40.1 h] |
| I-02.060 |  | COLOCACIÓN DE GEOTEXTIL NO TEJIDO 400 gr/m2 | 2d | 2022-12-12 | 2022-12-13 | I-02.050 | 1d | 0d | HH MAHRTUNEL [67 h] |
| I-02.070 |  | TRANSPORTE DE ROCA | 6d | 2022-12-12 | 2022-12-17 | I-02.060 SS | 1d | 0d | ROCA [108] |
| I-02.080 |  | COLOCACIÓN Y ACOMODO DE ROCA EN UÑA DEL DIQUE | 2d | 2022-12-13 | 2022-12-14 | I-02.070 SS+1d, D.03.090 | 1d | 0d |  |
| I-02.090 |  | COLOCACIÓN Y ACOMODO DE ROCA EN TALUD DEL DIQUE | 4d | 2022-12-15 | 2022-12-18 | I-02.080 | 1d | 0d |  |
|  | 2 | **PROTECCION DE TALUDES (A4-PT-I-03)** |  | 2022-12-12 | 2022-12-26 |  |  |  |  |
| I-03.010 |  | DESBROCE Y LIMPIEZA EN ZONA NO BOSCOSA | 1d | 2022-12-12 | 2022-12-12 | D.04.050, I-02.050 | 2d | 0d | HH MAHRTUNEL [23 h] |
| I-03.012 |  | TRANSPORTE DE MATERIAL EXCEDENTE | 1d | 2022-12-12 | 2022-12-12 | I-03.010 SS | 18d |  | HH MAHRTUNEL [227.1 h] |
| I-03.020 |  | RELLENO ESTRUCTURAL CON MATERIAL PROPIO EN TALUD EXISTENTE | 2d | 2022-12-13 | 2022-12-14 | I-03.010 | 2d | 0d |  |
| I-03.030 |  | EXCAVACIÓN EN TERRENO NATURAL CON EQUIPO | 1d | 2022-12-15 | 2022-12-15 | I-03.020 | 2d | 0d | HH MAHRTUNEL [56 h] |
| I-03.040 |  | PERFILADO Y COMPACTACIÓN EN ZONA DE CORTE | 1d | 2022-12-16 | 2022-12-16 | I-03.030 | 2d | 0d | HH MAHRTUNEL [40.1 h] |
| I-03.060 |  | COLOCACIÓN DE GEOTEXTIL NO TEJIDO 400 gr/m2 | 2d | 2022-12-17 | 2022-12-18 | I-03.040 | 2d | 0d | HH MAHRTUNEL [67 h] |
| I-03.070 |  | TRANSPORTE DE ROCA | 8d | 2022-12-17 | 2022-12-24 | I-03.060 SS | 2d | 1d | ROCA [529] |
| I-03.080 |  | COLOCACIÓN Y ACOMODO DE ROCA EN UÑA DEL DIQUE | 4d | 2022-12-19 | 2022-12-22 | I-03.070 SS+1d, I-02.090 | 1d | 0d |  |
| I-03.090 |  | COLOCACIÓN Y ACOMODO DE ROCA EN TALUD DEL DIQUE | 4d | 2022-12-23 | 2022-12-26 | I-03.080 | 1d |  |  |
|  | 3 | **PROTECCIÓN DEL CAUCE CON ENROCADO (A4-PT-PLR-01)-AGUAS ARRIBA** |  | 2022-11-27 | 2022-12-06 |  |  |  |  |
| PLR-01-060 |  | DESBROCE Y LIMPIEZA EN ZONA NO BOSCOSA | 2d | 2022-11-27 | 2022-11-28 | MV.040 | 0d |  |  |
| PLR-01-070 |  | EXCAVACIÓN EN MATERIAL SUELTO CON EQUIPO | 3d | 2022-11-29 | 2022-12-01 | PLR-01-060 | 0d |  |  |
| PLR-01-080 |  | PERFILADO Y COMPACTACIÓN CON EQUIPO DE FONDO DE EXCAVACIÓN | 2d | 2022-12-01 | 2022-12-02 | PLR-01-070 FF+1d | 0d |  |  |
| PLR-01-090 |  | TRANSPORTE DE ROCA | 5d | 2022-12-01 | 2022-12-05 | PLR-01-080 SS | 4d | 0d | ROCA [541] |
| PLR-01-100 |  | COLOCACIÓN DE ROCA EN CAUCE | 5d | 2022-12-02 | 2022-12-06 | PLR-01-090 SS+1d | 4d |  |  |

| ID | WBS | Activity | Duration | Start | Finish | Predecessors | Total float | Free float | Resources |
| --- | --- | --- | --- | --- | --- | --- | --- | --- | --- |
|  | 9 | **DIQUE DE TIERRA COMPACTADA (A4-PT- D-04)** |  | 2022-12-03 | 2022-12-17 |  |  |  |  |
| D.04.010 |  | DESBROCE Y LIMPIEZA EN ZONA NO BOSCOSA | 2d | 2022-12-03 | 2022-12-04 | PLR-01-080 | 0d |  |  |
| D.04.020 |  | TRANSPORTE DE MATERIAL EXCEDENTE | 2d | 2022-12-03 | 2022-12-04 | D.04.010 SS | 26d |  |  |
| D.04.030 |  | CONFORMACION DE CUERPO DE DIQUE | 3d | 2022-12-05 | 2022-12-07 | D.04.010 | 0d |  |  |
| D.04.040 |  | EXCAVACIÓN EN TERRENO NATURAL CON EQUIPO | 2d | 2022-12-07 | 2022-12-08 | D.04.030 FF+1d | 0d |  |  |
| D.04.050 |  | PERFILADO Y COMPACTACIÓN EN ZONA DE CORTE | 2d | 2022-12-08 | 2022-12-09 | D.04.040 FF+1d | 0d |  | HH MAHRTUNEL [40.1 h] |
| D.04.060 |  | COLOCACIÓN DE GEOTEXTIL NO TEJIDO 400 gr/m2 | 2d | 2022-12-10 | 2022-12-11 | D.04.050 | 0d |  | HH MAHRTUNEL [67 h] |
| D.04.070 |  | TRANSPORTE DE ROCA | 5d | 2022-12-10 | 2022-12-14 | D.04.060 SS | 0d |  | ROCA [205] |
| D.04.080 |  | COLOCACIÓN Y ACOMODO DE ROCA EN UÑA DEL DIQUE | 2d | 2022-12-11 | 2022-12-12 | D.04.070 SS+1d, PLR-01-100 | 0d |  |  |
| D.04.090 |  | COLOCACIÓN Y ACOMODO DE ROCA EN TALUD DEL DIQUE | 4d | 2022-12-13 | 2022-12-16 | D.04.080 | 0d |  |  |
| D.04.100 |  | CONFORMACIÓN DE MATERIAL GRANULAR EN CORONA DE DIQUE (e=0.30 m) | 1d | 2022-12-17 | 2022-12-17 | D.04.090 | 13d |  | HH MAHRTUNEL [285.7 h] |
|  | 4 | **DIQUE DE TIERRA COMPACTADA (A4-PT- D-05)** |  | 2022-12-09 | 2022-12-27 |  |  |  |  |
| D.05.010 |  | DESBROCE Y LIMPIEZA EN ZONA NO BOSCOSA | 2d | 2022-12-09 | 2022-12-10 | D.04.040 | 0d |  | HH MAHRTUNEL [23 h] |
| D.05.020 |  | TRANSPORTE DE MATERIAL EXCEDENTE | 2d | 2022-12-09 | 2022-12-10 | D.05.010 SS | 16d | 10d | HH MAHRTUNEL [227.1 h] |
| D.05.030 |  | CONFORMACION DE CUERPO DE DIQUE | 5d | 2022-12-11 | 2022-12-15 | D.05.010 | 0d |  |  |
| D.05.040 |  | EXCAVACIÓN EN TERRENO NATURAL CON EQUIPO | 2d | 2022-12-15 | 2022-12-16 | D.05.030 FF+1d | 0d |  |  |
| D.05.050 |  | PERFILADO Y COMPACTACIÓN EN ZONA DE CORTE | 3d | 2022-12-15 | 2022-12-17 | D.05.040 FF+1d | 0d |  | HH MAHRTUNEL [40.1 h] |
| D.05.070 |  | COLOCACIÓN DE GEOTEXTIL NO TEJIDO 400 gr/m2 | 3d | 2022-12-16 | 2022-12-18 | D.05.050 SS+1d | 0d |  | HH MAHRTUNEL [67 h] |
| D.05.080 |  | TRANSPORTE DE ROCA | 9d | 2022-12-16 | 2022-12-24 | D.05.070 SS | 0d |  | ROCA [677] |
| D.05.090 |  | COLOCACIÓN Y ACOMODO DE ROCA EN UÑA DEL DIQUE | 4d | 2022-12-17 | 2022-12-20 | D.05.080 SS+1d, D.04.090 | 0d |  |  |
| D.05.100 |  | COLOCACIÓN Y ACOMODO DE ROCA EN TALUD DEL DIQUE | 5d | 2022-12-21 | 2022-12-25 | D.05.090 | 0d |  |  |
| D.05.110 |  | CONFORMACIÓN DE MATERIAL GRANULAR EN CORONA DE DIQUE (e=0.30 m) | 2d | 2022-12-26 | 2022-12-27 | D.05.100 | 0d |  | HH MAHRTUNEL [285.7 h] |
|  | 7 | **REPOSICIÓN DE CAMINO DE ACCESO (A4-RC-1)** |  | 2022-12-18 | 2022-12-23 |  |  |  |  |
| RC.010 |  | DESBROCE Y LIMPIEZA EN ZONA NO BOSCOSA | 1d | 2022-12-18 | 2022-12-18 | D.05.050 | 4d | 0d | HH MAHRTUNEL [24.8 h] |
| RC.020 |  | EXCAVACIÓN EN MATERIAL SUELTO CON EQUIPO | 2d | 2022-12-19 | 2022-12-20 | RC.010 | 4d | 0d | HH MAHRTUNEL [30.2 h] |
| RC.030 |  | PERFILADO Y COMPACTACIÓN EN ZONA DE CORTE | 2d | 2022-12-21 | 2022-12-22 | RC.020 | 4d | 0d | HH MAHRTUNEL [46.2 h] |
| RC.040 |  | MATERIAL AFIRMADO e=25 cm | 1d | 2022-12-23 | 2022-12-23 | RC.030 | 4d |  | HH MAHRTUNEL [177.2 h] |

## Issues

| Issue | Status | Raised | Activity | Notes |
| --- | --- | --- | --- | --- |
| Free Float (days) is 0 on Activity: HP.020 | IS_Open | 2020-08-11 | HP.010 | ? |
| Free Float (days) is 0 on Activity: HP.030 | IS_Open | 2020-08-11 | HP.040 | ? |
| Free Float (days) is 0 on Activity: TP.010 | IS_Open | 2020-08-11 | OP.010 | ? |
| (New Issue) | IS_Open | 2020-06-01 |  | ? |
